# Pixel_mechanics

Schedule from MS Project, 1999-10-01 to 2006-07-24, costs in $.
LBNL

## Calendars

- Standard: Mon-Fri 08:00-12:00, 13:00-17:00; Sat-Sun off.

## Resources

| Resource | Group | Rate |
| --- | --- | --- |
| LBLj SP PRJ | LBL | 67.53 |
| LBLj EE PRJ | LBL | 70.95 |
| LBLj ME PRJ | LBL | 70.95 |
| LBLj DS PRJ | LBL | 31.52 |
| LBLj ET PRJ | LBL | 31.52 |
| LBLj MT PRJ | LBL | 31.52 |
| LBLj AS PRJ | LBL | 30.01 |
| LBLj OA PRJ | LBL | 30.01 |
| LBLj CL PRJ | LBL | 20.02 |
| LBLj SH PRJ | LBL | 52.44 |
| LBLj TS PRJ | LBL | 52.44 |
| LBLj ST PRJ | LBL | 15.11 |
| LBLj PM PRJ | LBL | 0.11 |
| LBLj S PRJ | LBL |  |
| LBLj TR PRJ | LBL | 0.11 |
| LBLj LW PRJ | LBL | 0.11 |
| LBLj RD PRJ | LBL | 0.05 |
| LBLj HI PRJ | LBL | 0.05 |
| LBLs SP PRJ | LBL | 100 |
| LBLs EE PRJ | LBL | 105.06 |
| LBLs ME PRJ | LBL | 105.06 |
| LBLs DS PRJ | LBL | 49.96 |
| LBLs ET PRJ | LBL | 49.96 |
| LBLs MT PRJ | LBL | 49.96 |
| LBLs AS PRJ | LBL | 47.56 |
| LBLs OA PRJ | LBL | 47.56 |
| LBLs CL PRJ | LBL | 22.06 |
| LBLs SH PRJ | LBL | 52.44 |
| LBLs TS PRJ | LBL | 49.91 |
| LBLs ST PRJ | LBL | 15.11 |
| LBLs PM PRJ | LBL | 0.11 |
| LBLs S PRJ | LBL |  |
| LBLs TR PRJ | LBL | 0.11 |
| LBLs LW PRJ | LBL | 0.11 |
| LBLs RD PRJ | LBL | 0.05 |
| LBLs HI PRJ | LBL | 0.05 |
| SUNYA SP PRJ | SUNYA |  |
| SUNYA EE PRJ | SUNYA |  |
| SUNYA ME PRJ | SUNYA |  |
| SUNYA DS PRJ | SUNYA | 27.93 |
| SUNYA ET PRJ | SUNYA | 27.93 |
| SUNYA MT PRJ | SUNYA | 27.93 |
| SUNYA AS PRJ | SUNYA | 27.93 |
| SUNYA OA PRJ | SUNYA | 27.93 |
| SUNYA CL PRJ | SUNYA |  |
| SUNYA SH PRJ | SUNYA | 27.93 |
| SUNYA TS PRJ | SUNYA | 27.93 |
| SUNYA ST PRJ | SUNYA | 14.7 |
| SUNYA PM PRJ | SUNYA |  |
| SUNYA S PRJ | SUNYA |  |
| SUNYA TR PRJ | SUNYA |  |
| SUNYA LW PRJ | SUNYA |  |
| SUNYA RD PRJ | SUNYA | 0.47 |
| SUNYA HI PRJ | SUNYA |  |
| UNM SP PRJ | UNM | 40.32 |
| UNM EE PRJ | UNM | 43.95 |
| UNM ME PRJ | UNM | 40.32 |
| UNM DS PRJ | UNM | 22.68 |
| UNM ET PRJ | UNM | 22.68 |
| UNM MT PRJ | UNM | 22.68 |
| UNM AS PRJ | UNM | 22.68 |
| UNM OA PRJ | UNM | 22.68 |
| UNM CL PRJ | UNM | 18.9 |
| UNM SH PRJ | UNM | 49.14 |
| UNM TS PRJ | UNM | 49.14 |
| UNM ST PRJ | UNM | 10.99 |
| UNM PM PRJ | UNM |  |
| UNM S PRJ | UNM |  |
| UNM TR PRJ | UNM |  |
| UNM LW PRJ | UNM |  |
| UNM RD PRJ | UNM |  |
| UNM HI PRJ | UNM |  |
| UOK SP PRJ | UOK | 45.57 |
| UOK EE PRJ | UOK | 45.57 |
| UOK ME PRJ | UOK | 45.57 |
| UOK DS PRJ | UOK | 31.6 |
| UOK ET PRJ | UOK | 33.7 |
| UOK MT PRJ | UOK | 31.6 |
| UOK AS PRJ | UOK | 31.6 |
| UOK OA PRJ | UOK | 31.6 |
| UOK CL PRJ | UOK | 13.23 |
| UOK SH PRJ | UOK | 13.23 |
| UOK TS PRJ | UOK | 13.23 |
| UOK ST PRJ | UOK | 10.99 |
| UOK PM PRJ | UOK |  |
| UOK S PRJ | UOK |  |
| UOK TR PRJ | UOK | 0.15 |
| UOK LW PRJ | UOK |  |
| UOK RD PRJ | UOK |  |
| UOK HI PRJ | UOK |  |
| OSU PM PRJ | OSU |  |
| OSU LW PRJ | OSU |  |
| OSU ST PRJ | OSU | 11.61 |
| OSU ET PRJ | OSU | 36.5 |
| OSU EE PRJ | OSU | 66.36 |
| OSU CL PRJ | OSU | 21.56 |
| OSU MT PRJ | OSU | 36.5 |
| OSU HI PRJ | OSU |  |

## Schedule

| ID | WBS | Task | Type | Duration | Start | Finish | Predecessors | Total slack | Free slack | Constraint | Resources | Work | Cost |
| --- | --- | --- | --- | --- | --- | --- | --- | --- | --- | --- | --- | --- | --- |
| 1 | 1.1.1 | **US ATLAS Pixel Project** |  | 1776d | 1999-10-01 | 2006-07-24 |  | 0d |  |  |  | 60.49h | 31,740.41 |
| 2 | 1.1.1.1 | **Mechanics** |  | 994d | 2002-10-01 | 2006-07-24 |  | 0d |  |  |  |  | 18,678 |
| 3 | 1.1.1.1.1 | **Design** |  | 261d | 2004-10-01 | 2005-09-30 |  | 210d |  |  |  |  | 12,000 |
| 4 | 1.1.1.1 | Mechanics Engineering FY05 $s |  | 261d | 2004-10-01 | 2005-09-30 |  | 210d |  | start no earlier than 2004-10-01 | LBLs TR PRJ |  | 12,000 |
| 5 | 1.1.1.2 | PP1 Interfaces PRR | milestone | 0d | 2005-02-23 | 2005-02-23 |  | 368d |  | start no earlier than 2005-02-23 |  |  |  |
| 6 | 1.1.1.1.2 | **Development/Prototypes** |  | 580d | 2002-10-01 | 2004-12-20 |  | 414d |  |  |  |  |  |
| 7 | 1.1.2.1 | Development/Prototypes FY05 $s |  | 186d | 2003-10-01 | 2004-06-16 |  | 547d |  | start no earlier than 2003-10-01 |  |  |  |
| 8 | 1.1.2.2 | Service panel/PP1 development |  | 580d | 2002-10-01 | 2004-12-20 |  | 414d | 0d | start no earlier than 2002-10-01 |  |  |  |
| 9 | 1.1.2.3 | Service panel/PP1 development complete | milestone | 0d | 2004-12-20 | 2004-12-20 | 8 | 414d |  |  |  |  |  |
| 10 | 1.1.1.1.3 | **Production** |  | 994d | 2002-10-01 | 2006-07-24 |  | 0d |  |  |  |  | 6,678 |
| 11 | 1.1.3.1 | Production FY05 $s |  | 261d | 2004-10-01 | 2005-09-30 |  | 210d |  | start no earlier than 2004-10-01 | LBLs PM PRJ |  | 6,678 |
| 12 | 1.1.3.2 | Production FY06 $s |  | 60d | 2005-10-03 | 2005-12-23 |  | 150d |  | start no earlier than 2005-10-01 |  |  |  |
| 13 | 1.1.3.3 | Disk Sector Fabrication |  | 700d | 2002-10-01 | 2005-06-06 |  | 294d |  | start no earlier than 2002-10-01 |  |  |  |
| 14 | 1.1.3.4 | Support tube fabrication |  | 400d | 2003-08-01 | 2005-02-10 |  | 296d | 0d | start no earlier than 2003-08-01 |  |  |  |
| 15 | 1.1.3.5 | Service panel/PP1 fabrication |  | 452d | 2004-04-01 | 2005-12-23 |  | 150d |  | start no earlier than 2004-04-01 |  |  |  |
| 16 | 1.1.3.6 | Disk Assembly/Test |  | 146d | 2005-01-10 | 2005-08-01 |  | 24d | 0d | start no earlier than 2005-01-10 |  |  |  |
| 17 | Sil L2/9; Sil L3/1 | Disk System at CERN | milestone | 0d | 2005-08-29 | 2005-08-29 | 16FS+20d | 24d | 0d | start no earlier than 2003-04-03 |  |  |  |
| 18 | 1.1.3.8 | Beam pipe support fabrication |  | 350d | 2003-10-01 | 2005-02-01 |  | 303d | 7d | start no earlier than 2003-10-01 |  |  |  |
| 19 | 1.1.3.9 | Trial assembly pixel package/PST |  | 20d | 2005-02-11 | 2005-03-10 | 18, 14 | 296d | 0d |  |  |  |  |
| 20 | 1.1.3.10 | PST at CERN | milestone | 0d | 2005-06-02 | 2005-06-02 | 19FS+60d | 296d |  |  |  |  |  |
| 21 | 1.1.3.11 | TC PST RFI date | milestone | 0d | 2005-11-30 | 2005-11-30 |  | 168d |  | start no earlier than 2005-11-30 |  |  |  |
| 22 | 1.1.3.12 | System Assembly/Test at CERN |  | 270d | 2005-06-15 | 2006-06-27 | 17FS-60d | 18d | 0d | start no earlier than 2005-06-15 |  |  |  |
| 23 | 1.1.3.13 | Pixel System Ready for Installation | milestone | 0d | 2006-06-27 | 2006-06-27 | 22 | 18d |  |  |  |  |  |
| 24 | 1.1.3.14 | TC RFI date for pixel installation | milestone | 0d | 2006-02-07 | 2006-02-07 |  | 119d |  | start no earlier than 2006-02-07 |  |  |  |
| 25 | 1.1.3.15 | Start pixel in-pit installation | milestone | 0d | 2006-07-24 | 2006-07-24 |  | 0d |  | start no earlier than 2006-07-24 |  |  |  |
| 27 | 1.1.1.2 | Sensors | milestone | 0d | 1999-10-01 | 1999-10-01 |  | 1776d |  |  |  |  |  |

Notes:
- 16: Disk is assembled as sectors are completed and tested. Disks inserted in frame as completed.
- 24: This is estimate. Final installation schedule not firm.

| ID | WBS | Task | Type | Duration | Start | Finish | Predecessors | Total slack | Free slack | Constraint | Resources | Work | Cost |
| --- | --- | --- | --- | --- | --- | --- | --- | --- | --- | --- | --- | --- | --- |
| 29 | 1.1.1.3 | **Electronics** |  | 393d | 2003-10-01 | 2005-04-01 |  | 340d |  |  |  |  |  |
| 30 | 1.1.1.3.3 | **Production** |  | 393d | 2003-10-01 | 2005-04-01 |  | 340d |  |  |  |  |  |
| 31 | 1.3.1.1 | Production FY05 $s |  | 131d | 2004-10-01 | 2005-04-01 |  | 340d |  | start no earlier than 2004-10-01 |  |  |  |
| 32 | 1.3.1.2 | FE Production |  | 290d | 2003-10-01 | 2004-11-09 |  | 443d | 0d | start no earlier than 2003-10-01 |  |  |  |
| 33 | 1.3.1.3 | 100% FE wafers complete delivery | milestone | 0d | 2004-11-09 | 2004-11-09 | 32 | 443d |  |  |  |  |  |
| 34 | 1.3.1.4 | Test FE IBM wafers |  | 350d | 2003-12-01 | 2005-04-01 |  | 340d | 0d | start no earlier than 2003-12-01 |  |  |  |
| 35 | 1.3.1.5 | FE Testing complete | milestone | 0d | 2005-04-01 | 2005-04-01 | 34 | 340d |  |  |  |  |  |
| 37 | 1.1.1.4 | **Flex Hybrids/Optical Hybrids** |  | 590d | 2003-09-01 | 2005-12-02 |  | 165d |  |  |  | 60.49h | 1,932.41 |
| 38 | 1.1.1.4.3 | **Production** |  | 590d | 2003-09-01 | 2005-12-02 |  | 165d |  |  |  | 60.49h | 1,932.41 |
| 39 | 1.4.1.1 | Hybrids Production FY05 $s |  | 101d | 2004-10-01 | 2005-02-18 |  | 370d |  | start no earlier than 2004-10-01 | UOK ET PRJ [1.4%]; OSU ET PRJ [4.8%]; OSU ST PRJ [1.2%] | 60.49h | 1,932.41 |
| 40 | 1.4.1.2 | Flex Hybrid Production/Load |  | 345d | 2003-09-01 | 2004-12-24 |  | 410d | 0d | start no earlier than 2003-09-01 |  |  |  |
| 41 | 1.4.1.3 | Flex complete | milestone | 0d | 2004-12-24 | 2004-12-24 | 40 | 410d |  | start no earlier than 2003-07-15 |  |  |  |
| 42 | 1.4.1.4 | Flex testing |  | 375d | 2003-09-15 | 2005-02-18 |  | 370d | 0d | start no earlier than 2003-09-15 |  |  |  |
| 43 | 1.4.1.5 | Flex testing complete | milestone | 0d | 2005-02-18 | 2005-02-18 | 42 | 370d |  |  |  |  |  |
| 44 | 1.4.1.6 | Optical Production/Test |  | 328d | 2004-09-01 | 2005-12-02 |  | 165d | 0d | start no earlier than 2004-09-01 |  |  |  |
| 45 | 1.4.1.7 | First optical boards | milestone | 0d | 2004-11-09 | 2004-11-09 | 44SS+50d | 443d |  |  |  |  |  |
| 46 | 1.4.1.8 | Optical production/test complete | milestone | 0d | 2005-12-02 | 2005-12-02 | 44 | 165d |  |  |  |  |  |
| 48 | 1.1.1.5 | **Modules** |  | 400d | 2003-12-15 | 2005-06-24 |  | 280d |  |  |  |  |  |
| 49 | 1.1.1.5.3 | **Production** |  | 400d | 2003-12-15 | 2005-06-24 |  | 280d |  |  |  |  |  |
| 50 | 1.5.1.1 | Modules Production FY05 $s |  | 9d | 2004-10-01 | 2004-10-13 |  | 462d |  | start no earlier than 2004-10-01 |  |  |  |
| 51 | 1.5.1.2 | FE Wafer Bump Deposition |  | 280d | 2003-12-15 | 2005-01-07 |  | 285d | 0d | start no earlier than 2003-12-15 |  |  |  |
| 52 | 1.5.1.3 | FE wafer thinning |  | 280d | 2004-01-12 | 2005-02-04 | 51SS+20d | 285d | 0d |  |  |  |  |
| 53 | 1.5.1.4 | FE Wafer Dicing |  | 280d | 2004-01-12 | 2005-02-04 | 52SS | 285d | 0d |  |  |  |  |
| 54 | 1.5.1.5 | FE Die sort |  | 370d | 2004-01-19 | 2005-06-17 | 53SS+5d | 285d |  |  |  |  |  |
| 55 | 1.5.1.6 | Bare module production/testing |  | 320d | 2004-02-02 | 2005-04-22 |  | 305d | 0d | start no earlier than 2004-02-02 |  |  |  |
| 56 | 1.5.1.7 | Module assembly/test |  | 340d | 2004-02-16 | 2005-06-03 | 55SS+10d | 295d | 0d |  |  |  |  |
| 57 | 1.5.1.8 | Complete testing modules | milestone | 0d | 2005-06-03 | 2005-06-03 | 56 | 295d |  |  |  |  |  |
| 58 | 1.5.1.9 | Module attach to disk sectors |  | 190d | 2004-09-27 | 2005-06-17 |  | 280d | 0d | start no earlier than 2004-09-27 |  |  |  |
| 59 | 1.5.1.10 | Test disk sectors |  | 190d | 2004-10-04 | 2005-06-24 | 58SS+5d | 280d | 0d |  |  |  |  |
| 60 | 1.5.1.11 | Complete testing disk sectors | milestone | 0d | 2005-06-24 | 2005-06-24 | 59 | 280d |  |  |  |  |  |

Notes:
- 32: Assumes Temic. 265 wafers required.
- 34: About 4 wafers per day all sites.
- 51: Includes B-layer
- 52: Includes B-layer
- 53: Includes B-layer
- 54: Includes B-layer
- 55: About 35 modules per week. Peak rate from two vendors is expected to be 40 modules per week.
- 56: About 35 modules per week.
- 58: About one sector every four days. This is about 1/2 of expected rate.
- 59: About one sector every four days. This is about 1/2 of expected rate.

| ID | WBS | Task | Duration | Start | Finish | Total slack | Constraint | Resources | Cost |
| --- | --- | --- | --- | --- | --- | --- | --- | --- | --- |
| 62 | 1.1.1.6 | **Beam/System Test Support** | 261d | 2004-10-01 | 2005-09-30 | 210d |  |  | 11,130 |
| 63 | 1.6.1 | **System Test Support** | 261d | 2004-10-01 | 2005-09-30 | 210d |  |  | 11,130 |
| 64 | 1.6.1.1 | System Test Support FY05 $s | 261d | 2004-10-01 | 2005-09-30 | 210d | start no earlier than 2004-10-01 | LBLj PM PRJ | 11,130 |
